# vaisala_alakoski

Schedule from MS Project, 2015-11-16 to 2016-03-22.
Metropolia AMK

## Calendars

- Standard: Mon-Fri 08:00-12:00, 13:00-17:00; Sat-Sun off.

## Resources

| Resource |
| --- |
| Risto |
| Heikki |
| Pekka |
| Jukka |
| Ari |

## Schedule

| ID | Task | Type | Duration | Start | Finish | Predecessors | Resources | Work |
| --- | --- | --- | --- | --- | --- | --- | --- | --- |
| 1 | Projektin hyväksyttäminen ja aloitus | milestone, manual | 0d | 2015-11-16 | 2015-11-16 |  |  |  |
| 2 | Eri apuvälineiden tutkimista | manual | 15d | 2015-11-16 | 2015-12-04 | 1 | Risto | 120h |
| 3 | Käytettävä apuväline valittu | milestone, manual | 0d | 2015-12-07 | 2015-12-07 | 2 |  |  |
| 4 | Prototyypin suunnittelu, valmistus ja testaus | manual | 10d | 2015-12-07 | 2015-12-18 | 3 | Risto | 80h |
| 5 | Virallinen aloituspalaveri | milestone, manual | 0h | 2015-12-18 | 2015-12-18 |  |  |  |
| 6 | Rampin suunnittelua ja kehitystä | manual | 5d | 2016-01-11 | 2016-01-15 | 4 | Risto | 40h |
| 7 | Projektisuunnitelman 1. versio valmis | milestone, manual | 0d | 2016-01-22 | 2016-01-22 |  | Risto |  |
| 8 | Työpiirustuksen tekoa | manual | 5d | 2016-01-11 | 2016-01-15 | 4 | Risto | 40h |
| 9 | Työpiirustus valmis | milestone, manual | 0d | 2016-01-21 | 2016-01-21 |  |  |  |
| 10 | Materiaalin valitseminen | manual | 1d | 2016-01-21 | 2016-01-21 | 9 | Risto | 8h |
| 11 | Materiaalien hankinta | manual | 1d | 2016-01-22 | 2016-01-22 | 10 | Ari | 8h |
| 12 | Rampin rakentaminen | manual | 1d | 2016-03-10 | 2016-03-10 | 11 | Risto | 8h |
| 13 | Valmiin rampin testausta | manual | 1d | 2016-03-11 | 2016-03-11 | 12 | Risto | 8h |
| 14 | Loppuraportin kirjoittaminen | manual | 1d | 2016-03-22 | 2016-03-22 |  | Risto | 8h |
